# Cronograma pinturas fotoluminiscentes

Schedule from MS Project, 2024-04-01 to 2025-07-22, status date 2024-08-30, costs in $, A marks actual dates.

## Calendars

- Estándar: Mon-Fri 09:00-13:00, 15:00-19:00; Sat-Sun off.

## Resources

| Resource | Group |
| --- | --- |
| Ingeniero Quimico | 100% |
| Ingeniero ambiental | 100% |
| Operativo 1 | 100% |
| Operativo 2 | 100% |
| Operativo 3 | 100% |
| Gerente de proyecto | 100% |
| Secretaria | 100% |
| Encuestador 1 | 100% |
| Encuestador 2 | 100% |
| Encuestador 3 | 100% |
| Juridico 1 | 100% |
| Contador | 100% |
| Resina |  |
| Solvente |  |
| Pigmentos organicos |  |
| Estearato de aluminio |  |
| Etiquetas |  |
| Envase |  |
| Batidora |  |
| Marmita |  |
| Bodega |  |
| Servicios publicos |  |
| Resma de papel |  |
| Impresora |  |
| Portatil |  |
| Escritorio |  |
| Silla |  |

## Schedule

| ID | WBS | Task | Duration | Start | Finish | Predecessors | Complete | Remaining | Baseline start | Baseline finish | Baseline duration | Total slack | Cost | Baseline cost | Actual cost |
| --- | --- | --- | --- | --- | --- | --- | --- | --- | --- | --- | --- | --- | --- | --- | --- |
| 1 | 1 | **Pinturas fotoluminiscentes** | 342d | 2024-04-01 A | 2025-07-22 |  | 27% | 248.33d | 2024-04-01 | 2025-07-22 | 342d | 0d | 60,900,000 | 62,900,000 | 30,941,000 |
| 2 | 1.1 | **Laboratorio** | 80d | 2024-04-01 A | 2024-07-19 A |  | 100% |  | 2024-04-01 | 2024-07-19 | 80d |  | 29,200,000 | 31,200,000 | 29,200,000 |
| 3 | 1.1.1 | **Planeación** | 20d | 2024-04-01 A | 2024-04-26 A |  | 100% |  | 2024-04-01 | 2024-04-26 | 20d |  | 6,000,000 | 8,000,000 | 6,000,000 |
| 4 | 1.1.1.1 | Determinación de las carácteristicas de la pintura | 20d | 2024-04-01 A | 2024-04-26 A |  | 100% |  | 2024-04-01 | 2024-04-26 | 20d |  | 6,000,000 | 8,000,000 | 6,000,000 |
| 5 | 1.1.2 | **Mezcla experimental** | 25d | 2024-04-29 A | 2024-05-31 A |  | 100% |  | 2024-04-29 | 2024-05-31 | 25d |  | 13,000,000 | 12,000,000 | 13,000,000 |
| 6 | 1.1.2.1 | Creación de la mezcla experimental | 25d | 2024-04-29 A | 2024-05-31 A | 4 | 100% |  | 2024-04-29 | 2024-05-31 | 25d |  | 13,000,000 | 12,000,000 | 13,000,000 |
| 7 | 1.1.3 | **Realización de pruebas** | 27d | 2024-06-03 A | 2024-07-09 A |  | 100% |  | 2024-06-03 | 2024-07-09 | 27d |  | 6,000,000 | 6,000,000 | 6,000,000 |
| 8 | 1.1.3.1 | Viscosidad en unidades Krebs | 6d | 2024-06-03 A | 2024-06-10 A | 6 | 100% |  | 2024-06-03 | 2024-06-10 | 6d |  | 400,000 | 400,000 | 400,000 |
| 9 | 1.1.3.2 | Poder cubriente, relación de contraste | 6d | 2024-06-03 A | 2024-06-10 A | 6 | 100% |  | 2024-06-03 | 2024-06-10 | 6d |  | 400,000 | 400,000 | 400,000 |
| 10 | 1.1.3.3 | Contenido de solidos, fracción de volumen | 6d | 2024-06-03 A | 2024-06-10 A | 6 | 100% |  | 2024-06-03 | 2024-06-10 | 6d |  | 400,000 | 400,000 | 400,000 |
| 11 | 1.1.3.4 | Finura de dispersión en unidades Hegman | 6d | 2024-06-03 A | 2024-06-10 A | 6 | 100% |  | 2024-06-03 | 2024-06-10 | 6d |  | 400,000 | 400,000 | 400,000 |
| 12 | 1.1.3.5 | Tiempo de secamiento para repintar | 6d | 2024-06-03 A | 2024-06-10 A | 6 | 100% |  | 2024-06-03 | 2024-06-10 | 6d |  | 400,000 | 400,000 | 400,000 |
| 13 | 1.1.3.6 | Resistencia a la abrasión humeda | 27d | 2024-06-03 A | 2024-07-09 A | 6 | 100% |  | 2024-06-03 | 2024-07-09 | 27d |  | 800,000 | 800,000 | 800,000 |
| 14 | 1.1.3.7 | Lavabilidad en porcentaje minimo | 27d | 2024-06-03 A | 2024-07-09 A | 6 | 100% |  | 2024-06-03 | 2024-07-09 | 27d |  | 800,000 | 800,000 | 800,000 |
| 15 | 1.1.3.8 | Resistencia al agua y al alcali | 6d | 2024-06-03 A | 2024-06-10 A | 6 | 100% |  | 2024-06-03 | 2024-06-10 | 6d |  | 600,000 | 600,000 | 600,000 |
| 16 | 1.1.3.9 | Entizamiento | 6d | 2024-06-03 A | 2024-06-10 A | 6 | 100% |  | 2024-06-03 | 2024-06-10 | 6d |  | 300,000 | 300,000 | 300,000 |
| 17 | 1.1.3.10 | Resistencia al cuarteamiento a alto espesor | 6d | 2024-06-03 A | 2024-06-10 A | 6 | 100% |  | 2024-06-03 | 2024-06-10 | 6d |  | 500,000 | 500,000 | 500,000 |
| 18 | 1.1.3.11 | Cultivo de microorganismos | 9d | 2024-06-03 A | 2024-06-13 A | 6 | 100% |  | 2024-06-03 | 2024-06-13 | 9d |  | 1,000,000 | 1,000,000 | 1,000,000 |
| 19 | 1.1.4 | **Lectura de datos** | 2d | 2024-07-10 A | 2024-07-11 A |  | 100% |  | 2024-07-10 | 2024-07-11 | 2d |  | 200,000 | 200,000 | 200,000 |
| 20 | 1.1.4.1 | Lectura de datos de las pruebas | 2d | 2024-07-10 A | 2024-07-11 A | 8, 9, 10, 11, 12, 13, 14, 15, 16, 17, 18 | 100% |  | 2024-07-10 | 2024-07-11 | 2d |  | 200,000 | 200,000 | 200,000 |
| 21 | 1.1.5 | **Retroalimentación** | 4d | 2024-07-10 A | 2024-07-15 A |  | 100% |  | 2024-07-10 | 2024-07-15 | 4d |  | 2,000,000 | 2,500,000 | 2,000,000 |
| 22 | 1.1.5.1 | Análisis de los datos y correcciones | 4d | 2024-07-10 A | 2024-07-15 A | 20SS | 100% |  | 2024-07-10 | 2024-07-15 | 4d |  | 2,000,000 | 2,500,000 | 2,000,000 |
| 23 | 1.1.6 | **Documentación** | 4d | 2024-07-16 A | 2024-07-19 A |  | 100% |  | 2024-07-16 | 2024-07-19 | 4d |  | 2,000,000 | 2,500,000 | 2,000,000 |
| 24 | 1.1.6.1 | Documentación de la formula final | 4d | 2024-07-16 A | 2024-07-19 A | 22 | 100% |  | 2024-07-16 | 2024-07-19 | 4d |  | 2,000,000 | 2,500,000 | 2,000,000 |

| ID | WBS | Task | Type | Duration | Start | Finish | Predecessors | Complete | Remaining | Baseline start | Baseline finish | Baseline duration | Total slack | Free slack | Cost | Baseline cost | Actual cost |
| --- | --- | --- | --- | --- | --- | --- | --- | --- | --- | --- | --- | --- | --- | --- | --- | --- | --- |
| 25 | 1.2 | **Fabricación** |  | 160d | 2024-07-22 A | 2025-02-28 |  | 8% | 147.47d | 2024-07-22 | 2025-02-28 | 160d | 0d |  | 9,300,000 | 9,300,000 | 741,000 |
| 26 | 1.2.1 | **Gramaje** |  | 160d | 2024-07-22 A | 2025-02-28 |  | 12% | 141.16d | 2024-07-22 | 2025-02-28 | 160d | 0d |  | 2,800,000 | 2,800,000 | 356,000 |
| 27 | 1.2.1.1 | Medición de cada uno de los elementos insertados a la mezcla |  | 80d | 2024-07-22 A | 2024-11-08 | 24 | 17% | 66.67d | 2024-07-22 | 2024-11-08 | 80d | 40.8d | 0d | 2,000,000 | 2,000,000 | 340,000 |
| 28 | 1.2.1.2 | Revisión final del peso de cada galón de pintura |  | 40d | 2025-01-06 A | 2025-02-28 | 27, 30, 32, 34 | 2% | 39.2d | 2025-01-06 | 2025-02-28 | 40d | 0d |  | 800,000 | 800,000 | 16,000 |
| 29 | 1.2.2 | **Dispersión** |  | 80d | 2024-07-22 A | 2024-11-08 |  | 7% | 74.4d | 2024-07-22 | 2024-11-08 | 80d | 40.8d |  | 1,000,000 | 1,000,000 | 70,000 |
| 30 | 1.2.2.1 | Reducción del tamaño de las particulas |  | 80d | 2024-07-22 A | 2024-11-08 | 27FF, 24 | 7% | 74.4d | 2024-07-22 | 2024-11-08 | 80d | 40.8d | 40d | 1,000,000 | 1,000,000 | 70,000 |
| 31 | 1.2.3 | **Mezcla inicial** |  | 120d | 2024-07-22 A | 2025-01-03 |  | 5% | 114d | 2024-07-22 | 2025-01-03 | 120d | 0.8d |  | 3,500,000 | 3,500,000 | 175,000 |
| 32 | 1.2.3.1 | Mezcla de las particulas con las demás |  | 120d | 2024-07-22 A | 2025-01-03 | 30FF, 24 | 5% | 114d | 2024-07-22 | 2025-01-03 | 120d | 0.8d | 0d | 3,500,000 | 3,500,000 | 175,000 |
| 33 | 1.2.4 | **Molido de pigmentos** |  | 80d | 2024-09-16 A | 2025-01-03 |  | 7% | 74.4d | 2024-09-16 | 2025-01-03 | 80d | 0.8d |  | 2,000,000 | 2,000,000 | 140,000 |
| 34 | 1.2.4.1 | Trituración de los grumos hasta obtener la fineza deseada |  | 80d | 2024-09-16 A | 2025-01-03 | 32FF, 24 | 7% | 74.4d | 2024-09-16 | 2025-01-03 | 80d | 0.8d | 0d | 2,000,000 | 2,000,000 | 140,000 |
| 35 | 1.3 | **Control** |  | 22d | 2025-03-03 | 2025-04-01 |  |  |  | 2025-03-03 | 2025-04-01 | 22d | 0d |  | 4,000,000 | 4,000,000 |  |
| 36 | 1.3.1 | **Finura** |  | 14d | 2025-03-03 | 2025-03-20 |  |  |  | 2025-03-03 | 2025-03-20 | 14d | 0d |  | 1,000,000 | 1,000,000 |  |
| 37 | 1.3.1.1 | Finura de dispersión en unidades Hegman del producto teminado |  | 14d | 2025-03-03 | 2025-03-20 | 28 |  |  | 2025-03-03 | 2025-03-20 | 14d | 0d |  | 1,000,000 | 1,000,000 |  |
| 38 | 1.3.2 | **Color** |  | 15d | 2025-03-03 | 2025-03-21 |  |  |  | 2025-03-03 | 2025-03-21 | 15d | 7d |  | 1,500,000 | 1,500,000 |  |
| 39 | 1.3.2.1 | Medición de color con espectrofotómetro |  | 15d | 2025-03-03 | 2025-03-21 | 37SS |  |  | 2025-03-03 | 2025-03-21 | 15d | 7d |  | 1,500,000 | 1,500,000 |  |
| 40 | 1.3.3 | **Estabilización** |  | 22d | 2025-03-03 | 2025-04-01 |  |  |  | 2025-03-03 | 2025-04-01 | 22d | 0d |  | 1,500,000 | 1,500,000 |  |
| 41 | 1.3.3.1 | Prueba rápida de estabilidad de la emulsión |  | 22d | 2025-03-03 | 2025-04-01 | 37SS |  |  | 2025-03-03 | 2025-04-01 | 22d | 0d |  | 1,500,000 | 1,500,000 |  |
| 42 | 1.4 | **Envasado** |  | 222d | 2024-07-22 A | 2025-05-27 |  | 10% | 199.8d | 2024-07-22 | 2025-07-22 | 262d | 40d |  | 12,000,000 | 18,400,000 | 1,000,000 |
| 43 | 1.4.1 | **Etiqueta** |  | 202d | 2024-07-22 A | 2025-04-29 |  | 17% | 168.33d | 2024-07-22 | 2025-04-29 | 202d | 60d |  | 6,000,000 | 6,000,000 | 1,000,000 |
| 44 | 1.4.1.1 | Diseño de etiqueta |  | 20d | 2024-07-22 A | 2024-08-16 | 24 | 50% | 10d | 2024-07-22 | 2024-08-16 | 20d | 222d | 0d | 2,000,000 | 2,000,000 | 1,000,000 |
| 45 | 1.4.1.2 | Impresión |  | 20d | 2024-08-19 | 2024-09-13 | 44 |  |  | 2024-08-19 | 2024-09-13 | 20d | 222d |  | 3,000,000 | 3,000,000 |  |
| 46 | 1.4.1.3 | Pegado |  | 20d | 2025-04-02 | 2025-04-29 | 28, 39, 41 |  |  | 2025-04-02 | 2025-04-29 | 20d | 0d |  | 1,000,000 | 1,000,000 |  |
| 47 | 1.4.2 | **Sellado** |  | 40d | 2025-04-02 | 2025-05-27 |  |  |  | 2025-04-02 | 2025-07-22 | 80d | 0d |  | 6,000,000 | 12,400,000 |  |
| 48 | 1.4.2.1 | Empaquetado y sellado |  | 40d | 2025-04-02 | 2025-05-27 | 46SS |  |  | 2025-04-02 | 2025-05-27 | 40d | 0d |  | 6,000,000 | 6,000,000 |  |
| 49 | 1.5 | RESERVA DE CONTINGENCIA |  | 40d | 2025-05-28 | 2025-07-22 | 48 |  |  | 2025-05-28 | 2025-07-22 | 40d | 0d |  | 6,400,000 | 6,400,000 |  |
| 50 | 2 | Fin | milestone | 0d | 2025-07-22 | 2025-07-22 | 49 |  |  | 2025-07-22 | 2025-07-22 | 0d | 0d |  |  |  |  |
